# Proyecto de Reforestación

Schedule from Primavera P6, 2024-08-08 to 2026-01-12, data date 2024-08-08, costs in PEN.

## Calendars

- Corporate - Standard Full Time: Mon-Sun 08:00-16:00. Exceptions (off unless hours are given): 2024-08-10 08:00-16:00, 2024-08-17 08:00-16:00, 2024-08-24 08:00-16:00, 2024-08-31 08:00-16:00.

## Resources

| Resource | Group | Unit | Rate |
| --- | --- | --- | --- |
| Operario | labor |  | 3.43 |
| Peón | labor |  | 2.44 |
| Concreto Ciclopeo | material | m3 | 350 |
| Parantes de Madsera de 1 1/2 x 1 1/2" | material | Unid | 8.24 |
| Cinta de Señalización de Peligro | material | Unid | 52.46 |
| Ingeniero Residente de Obra | labor |  |  |
| Ing. SSOMA | labor |  |  |
| Jefe de Topografia | labor |  |  |
| Yeso | material | kg | 1.9 |
| Estacas de Madera | material | Unid | 3.5 |
| Cordel | material | m | 1 |
| Estación Total | equipment |  | 30 |
| Nivel Topografico | equipment |  | 5.3 |
| Herramientas Manuales | equipment |  |  |
| Retroexcavadora Case 590 SK | equipment |  | 185.5 |
| Camión Volquete de 15 m3 | equipment |  | 160 |
| Ing. Responsable de Calidad | labor |  |  |
| Sustrato | material | m3 | 58.35 |
| Zaranda | equipment |  | 6.36 |
| Camión Cisterna (2,500 GLNS.) | equipment |  | 160 |
| Tessaria Integrifolia (Pajaro Bobo) | material | Unid | 15 |
| Baccharis Latifolia (Chilco) | material | Unid | 15 |
| Schinus Molle (Molle) | material | Unid | 22.5 |
| Acacia Macracantha (Huarango) | material | Unid | 22.5 |
| Cal | material | kg | 15.89 |
| Clavos para Madera con Cabeza de 2 1/2" | material | kg | 7 |
| Cola Sintetica | material | gal | 15 |
| Madera Pumaquiro 6" | material | m2 | 30 |
| Insecticida Antitermitas | material | gal | 80 |
| Madera Huayruro | material | P2 | 3.5 |
| Plancha de Acero 8mm | material | kg | 9 |
| Madera Tornillo | material | P2 | 6 |
| Papelera de Reciclaje | material | Unid | 1200 |
| Hormigon | material | m3 | 55.5 |
| Agua Puesta en Obra | material | m3 | 13.5 |
| Banner Señalitica Digital | material | Unid | 90 |
| Cemento Porland Tipo I (42.5 kg) | material | bol | 22.3 |
| Movilización y Desmovilización de Equipos | material | Glob | 5000 |
| Compactadora Vibratoria Tipo Plancha 7 HP | equipment |  | 37.44 |
| Alambre Negro Recocido N° 08 | material | kg | 4.16 |
| Concreto Premezclado F'c = 280 kg/cm2 | material | m3 | 540 |
| Vibrador de Concreto 4 HP 1.25" | equipment |  | 7.27 |
| Andamio Metalico | equipment |  | 10 |
| Madera Tornillo 3" x 8" | material | Unid | 35 |
| Perno Hexagonal 1/2" x 17" | material | Unid | 6.5 |
| Arandela Plana de 1/2" | material | Unid | 2.5 |
| Tuerca 1/2" | material | Unid | 2.5 |
| Perno Hexagonal 5/8" x 6" | material | Unid | 7.35 |
| Arandela Plana de 5/8" | material | Unid | 2.75 |
| Tuerca 5/8" | material | Unid | 2.75 |
| Perno Hexagonal 3/4" x 16" | material | Unid | 6.3 |
| Arandela Plana de 3/4" | material | Unid | 2.3 |
| Tuerca 3/4" | material | Unid | 2.3 |
| Perno Hexagonal 1/2" x 6.5" | material | Unid | 6.5 |
| Salix Humboldtina (Sauce) | material | Unid | 30 |
| Alambre Negro Recocido N° 16 | material | kg | 4.16 |
| Malla Rashel | material | m | 10.08 |
| Madera de Eucalipto | material | Unid | 10.17 |
| Motosierra | equipment |  | 14.2 |
| Especies Arbóreas | material | Unid | 20 |
| Galvezia Fruticosa (Galvezia) | material | Unid | 15 |
| Bougainvellea Peruviana (Buganvilla) | material | Unid | 15 |
| Lippia Nodiflora (Bella Alfombra) | material | m2 |  |
| Material Granular | material | m3 | 55.5 |
| Arena | material | m3 | 68.5 |
| Tronco de Madera | material | Unid | 8 |
| Piedra Chancada 1/2" | material | m3 | 72.03 |
| Arena Gruesa | material | m3 | 63.55 |
| Mezcladora de Concreto 11 P3 (23 HP) | equipment |  | 24 |
| Acero Corrugado fy= 4200 kg/cm2 Grado 60 | material | kg | 4.18 |
| Acero Estructural A36 | material | kg | 13.5 |
| Tornillo Galvanizado D=1/4" Pasante A307 | material | Unid | 8.2 |
| Arandela Plana de 1/4" | material | Unid | 2.5 |
| Tuerca 1/4" | material | Unid | 2.5 |
| Perno de Anclaje de 1/4" Expansivo A307 L=57 mm | material | Unid | 7.5 |
| Perno de Anclaje de 1/4" Expansivo A307 L=114 mm | material | Unid | 12.5 |
| Tubo ASTM A500/A500M | material | m | 14.5 |

## Schedule

| ID | WBS | Activity | Duration | Start | Finish | Predecessors | Total float | Free float | Resources | Cost |
| --- | --- | --- | --- | --- | --- | --- | --- | --- | --- | --- |
|  | 1 | **Infraestructura Verde y Paisajismo - Paquete 01** |  | 2024-08-08 | 2026-01-12 |  |  |  |  |  |
|  | 1 | **Revegetación / Reforestación de La Ribera** |  | 2024-08-08 | 2026-01-12 |  |  |  |  |  |
|  | 1 | **Preparación del Terreno** |  | 2024-08-08 | 2026-01-12 |  |  |  |  |  |
| A1000 |  | Ubicación y Delimitación de la Zona de Trabajo | 7d | 2024-08-08 | 2024-08-14 |  | 0d |  | Operario [56 h]; Peón [56 h]; Concreto Ciclopeo [56 m3]; Parantes de Madsera de 1 1/2 x 1 1/2" [56 Unid]; Cinta de Señalización de Peligro [56 Unid]; Ingeniero Residente de Obra [56 h]; Ing. SSOMA [56 h] | 3,689.7 |
| A1010 |  | Trazado, Marcación y Estacado | 5d | 2024-08-11 | 2024-08-15 | A1000 SS+3d | 0d |  | Operario [40 h]; Peón [40 h]; Jefe de Topografia [40 h]; Yeso [40 kg]; Estacas de Madera [40 Unid]; Cordel [40 m]; Estación Total [40 h]; Nivel Topografico [40 h]; Herramientas Manuales [40 h]; Ingeniero Residente de Obra [40 h]; Ing. SSOMA [40 h] | 1,875.5 |
| A1020 |  | Limpieza y Desbroce del Terreno con Medios Manuales | 5d | 2024-08-13 | 2024-08-17 | A1010 SS+2d | 0d |  | Operario [40 h]; Peón [40 h]; Herramientas Manuales [40 h]; Ingeniero Residente de Obra [40 h]; Ing. SSOMA [40 h] | 207.5 |
| A1030 |  | Eliminación de Materiales de Desbroce (Incuye Transporte) | 1d | 2024-08-14 | 2024-08-14 | A1020 SS+1d | 0d |  | Ingeniero Residente de Obra [8 h]; Ing. SSOMA [8 h]; Operario [8 h]; Peón [8 h]; Herramientas Manuales [8 h]; Retroexcavadora Case 590 SK [8 h]; Camión Volquete de 15 m3 [8 h] | 2,805.5 |
| A1040 |  | Despedregado del Terreno con Medios Manuales | 5d | 2024-08-15 | 2024-08-19 | A1030 SS+1d | 0d |  | Ingeniero Residente de Obra [40 h]; Ing. SSOMA [40 h]; Peón [40 h]; Herramientas Manuales [40 h] | 86.4 |
| A1050 |  | Preparación y Aporte del Sustrato | 60d | 2024-08-20 | 2024-10-18 | A1040 | 0d |  | Ingeniero Residente de Obra [480 h]; Ing. SSOMA [480 h]; Ing. Responsable de Calidad [480 h]; Operario [480 h]; Peón [480 h]; Sustrato [480 m3]; Zaranda [480 h] | 33,876.6 |
| A1060 |  | Riego de Áreas Vegetadas con Camión Cisterna | 505d | 2024-08-26 | 2026-01-12 | A1070 SS+1d | 0d |  | Ingeniero Residente de Obra [720 h]; Ing. SSOMA [720 h]; Operario [720 h]; Camión Cisterna (2,500 GLNS.) [720 h] | 117,667.8 |
|  | 2 | **Especies Arbustiva** |  | 2024-08-25 | 2024-09-23 |  |  |  |  |  |
| A1070 |  | Tessaria Integrifolia (Pájaro Bobo) Incluye Siembra y Transporte | 15d | 2024-08-25 | 2024-09-08 | A1050 SS+5d | 0d |  | Ingeniero Residente de Obra [120 h]; Ing. SSOMA [120 h]; Ing. Responsable de Calidad [120 h]; Operario [120 h]; Peón [120 h]; Tessaria Integrifolia (Pajaro Bobo) [120 Unid]; Herramientas Manuales [120 h] | 2,422.5 |
| A1080 |  | Baccharis Latifolia (Chilco) Incluye Siembre y Transporte | 15d | 2024-09-09 | 2024-09-23 | A1070 | 266d | 0d | Ingeniero Residente de Obra [120 h]; Ing. SSOMA [120 h]; Ing. Responsable de Calidad [120 h]; Operario [120 h]; Peón [120 h]; Baccharis Latifolia (Chilco) [120 Unid]; Herramientas Manuales [120 h] | 2,422.5 |
|  | 3 | **Especies Arbóreas** |  | 2024-09-24 | 2024-10-23 |  |  |  |  |  |
| A1090 |  | Shinus Molle (Molle) Incuye Siembra y Transporte | 15d | 2024-09-24 | 2024-10-08 | A1080 | 266d | 0d | Ingeniero Residente de Obra [120 h]; Ing. SSOMA [120 h]; Ing. Responsable de Calidad [120 h]; Operario [120 h]; Peón [120 h]; Schinus Molle (Molle) [120 Unid]; Herramientas Manuales [120 h] | 3,322.5 |
| A1100 |  | Acacia Macracantha (Huarango) Incluye Siembra Y Transporte | 15d | 2024-10-09 | 2024-10-23 | A1090 | 266d | 0d | Ingeniero Residente de Obra [120 h]; Ing. SSOMA [120 h]; Ing. Responsable de Calidad [120 h]; Operario [120 h]; Peón [120 h]; Acacia Macracantha (Huarango) [120 Unid]; Herramientas Manuales [120 h] | 3,322.5 |
|  | 6 | **Arquitectura** |  | 2024-08-23 | 2024-09-17 |  |  |  |  |  |
|  | 1 | **Preparación del Terreno** |  | 2024-08-23 | 2024-08-28 |  |  |  |  |  |
| A1110 |  | Ubicación Y Delimitación De La Zona De Trabajo | 3d | 2024-08-23 | 2024-08-25 | A1000 SS+15d | 0d |  | Ingeniero Residente de Obra [24 h]; Ing. SSOMA [24 h]; Operario [24 h]; Peón [24 h]; Concreto Ciclopeo [24 m3]; Parantes de Madsera de 1 1/2 x 1 1/2" [24 Unid]; Cinta de Señalización de Peligro [24 Unid] | 1,581.3 |
| A1120 |  | Limpieza Y Desbroce Del Terreno Con Medios Manuales | 3d | 2024-08-23 | 2024-08-25 | A1110 SS | 0d |  | Ingeniero Residente de Obra [24 h]; Ing. SSOMA [24 h]; Operario [24 h]; Peón [24 h]; Herramientas Manuales [24 h] | 124.5 |
| A1140 |  | Despedregado Del Terreno Con Medios Manuales | 5d | 2024-08-24 | 2024-08-28 | A1120 SS+1d | 0d |  | Ingeniero Residente de Obra [40 h]; Ing. SSOMA [40 h]; Peón [40 h]; Herramientas Manuales [40 h] | 86.4 |
| A1130 |  | Eliminación De Materiales De Desbroce (Incluye Transporte) | 1d | 2024-08-26 | 2024-08-26 | A1120 | 504d |  | Ingeniero Residente de Obra [8 h]; Ing. SSOMA [8 h]; Operario [8 h]; Peón [8 h]; Herramientas Manuales [8 h]; Retroexcavadora Case 590 SK [8 h]; Camión Volquete de 15 m3 [8 h] | 2,805.5 |
|  | 2 | **Trabajos Provisionales** |  | 2024-08-29 | 2024-08-30 |  |  |  |  |  |
| A1150 |  | Trazado Y Replanteo S/Equipo Con Cal Blanca | 2d | 2024-08-29 | 2024-08-30 | A1140 | 0d |  | Ingeniero Residente de Obra [16 h]; Ing. SSOMA [16 h]; Operario [16 h]; Peón [16 h]; Cal [16 kg]; Estacas de Madera [16 Unid]; Herramientas Manuales [16 h] | 393.24 |

| ID | WBS | Activity | Duration | Start | Finish | Predecessors | Total float | Free float | Resources | Cost |
| --- | --- | --- | --- | --- | --- | --- | --- | --- | --- | --- |
|  | 3 | **Pasarela** |  | 2024-08-31 | 2024-09-11 |  |  |  |  |  |
| A1160 |  | Piso Entablado De Madera De Sección 1” X 6” Para Pasarela Elevada | 12d | 2024-08-31 | 2024-09-11 | A1150 | 482d | 0d | Ingeniero Residente de Obra [96 h]; Ing. SSOMA [96 h]; Ing. Responsable de Calidad [96 h]; Operario [96 h]; Peón [96 h]; Clavos para Madera con Cabeza de 2 1/2" [96 kg]; Cola Sintetica [96 gal]; Madera Pumaquiro 6" [96 m2]; Insecticida Antitermitas [96 gal]; Herramientas Manuales [96 h] | 13,170 |
| A1170 |  | Baranda De Madera De Huayruro De H=1.00 M, Para Pasarela | 12d | 2024-08-31 | 2024-09-11 | A1160 SS | 482d | 0d | Ingeniero Residente de Obra [96 h]; Ing. SSOMA [96 h]; Ing. Responsable de Calidad [96 h]; Operario [96 h]; Peón [96 h]; Clavos para Madera con Cabeza de 2 1/2" [96 kg]; Madera Huayruro [96 P2]; Insecticida Antitermitas [96 gal]; Herramientas Manuales [96 h] | 9,186 |
|  | 4 | **Mobiliario Urbano** |  | 2024-09-12 | 2024-09-17 |  |  |  |  |  |
| A1180 |  | Bancas De Madera Con Respaldar. Tipo T1 | 3d | 2024-09-12 | 2024-09-14 | A1170 | 482d | 0d | Ingeniero Residente de Obra [24 h]; Ing. SSOMA [24 h]; Ing. Responsable de Calidad [24 h]; Operario [24 h]; Peón [24 h]; Clavos para Madera con Cabeza de 2 1/2" [24 kg]; Plancha de Acero 8mm [24 kg]; Madera Tornillo [24 P2]; Insecticida Antitermitas [24 gal] | 2,572.5 |
| A1190 |  | Papeleras De Reciclaje De Acabado De Madera En Estructura De 4 (75 Litros C/U) | 1d | 2024-09-15 | 2024-09-15 | A1180 | 482d | 0d | Ingeniero Residente de Obra [8 h]; Ing. SSOMA [8 h]; Operario [8 h]; Peón [8 h]; Herramientas Manuales [8 h]; Papelera de Reciclaje [8 Unid] | 9,641.5 |
| A1200 |  | Panel Informativo H=1.25m. Tipo A | 2d | 2024-09-16 | 2024-09-17 | A1190 | 482d |  | Ingeniero Residente de Obra [16 h]; Ing. SSOMA [16 h]; Ing. Responsable de Calidad [16 h]; Operario [16 h]; Peón [16 h]; Clavos para Madera con Cabeza de 2 1/2" [16 kg]; Hormigon [16 m3]; Agua Puesta en Obra [16 m3]; Banner Señalitica Digital [16 Unid]; Cemento Porland Tipo I (42.5 kg) [16 bol]; Madera Tornillo [16 P2]; Herramientas Manuales [16 h] | 3,191.8 |
| A1210 |  | Panel Informativo H=2.10m. Tipo B | 2d | 2024-09-16 | 2024-09-17 | A1190 SS+1d | 482d |  | Ingeniero Residente de Obra [16 h]; Ing. SSOMA [16 h]; Ing. Responsable de Calidad [16 h]; Operario [16 h]; Peón [16 h]; Clavos para Madera con Cabeza de 2 1/2" [16 kg]; Hormigon [16 m3]; Agua Puesta en Obra [16 m3]; Banner Señalitica Digital [16 Unid]; Cemento Porland Tipo I (42.5 kg) [16 bol]; Madera Tornillo [16 P2]; Herramientas Manuales [16 h] | 3,191.8 |
|  | 5 | **Pasarela - Elementos Estructurales** |  | 2024-08-29 | 2024-11-05 |  |  |  |  |  |
|  | 1 | **Trabajos Preliminares** |  | 2024-08-29 | 2024-09-06 |  |  |  |  |  |
| A1220 |  | Trazo, Nivelacion Y Replanteo En Pasarela | 6d | 2024-08-29 | 2024-09-03 | A1150 SS | 0d |  | Ingeniero Residente de Obra [48 h]; Ing. SSOMA [48 h]; Ing. Responsable de Calidad [48 h]; Jefe de Topografia [48 h]; Nivel Topografico [48 h]; Yeso [48 kg]; Cordel [48 m]; Estación Total [48 h]; Herramientas Manuales [48 h] | 1,833.6 |
| A1230 |  | Movilización Y Desmovilización De Equipos | 3d | 2024-09-04 | 2024-09-06 | A1220 | 493d |  | Ingeniero Residente de Obra [24 h]; Movilización y Desmovilización de Equipos [24 Glob] | 120,000 |
|  | 2 | **Movimiento de Tierras** |  | 2024-09-04 | 2024-09-06 |  |  |  |  |  |
| A1240 |  | Excavación Con Maquinaria | 2d | 2024-09-04 | 2024-09-05 | A1220 | 0d |  | Ingeniero Residente de Obra [16 h]; Ing. SSOMA [16 h]; Operario [16 h]; Herramientas Manuales [16 h]; Retroexcavadora Case 590 SK [16 h] | 3,016.44 |
| A1250 |  | Acarreo Y Eliminación De Material Excedente | 1d | 2024-09-06 | 2024-09-06 | A1240 | 0d |  | Ingeniero Residente de Obra [8 h]; Ing. SSOMA [8 h]; Operario [8 h]; Peón [8 h]; Herramientas Manuales [8 h]; Retroexcavadora Case 590 SK [8 h]; Camión Volquete de 15 m3 [8 h] | 2,805.5 |
|  | 3 | **Rellenos** |  | 2024-09-07 | 2024-09-13 |  |  |  |  |  |
| A1260 |  | Relleno Con Material Propio | 7d | 2024-09-07 | 2024-09-13 | A1250 | 0d |  | Ingeniero Residente de Obra [56 h]; Ing. SSOMA [56 h]; Operario [56 h]; Peón [56 h]; Herramientas Manuales [56 h]; Compactadora Vibratoria Tipo Plancha 7 HP [56 h] | 2,387.14 |
|  | 4 | **Obras de Concreto Simple** |  | 2024-09-14 | 2024-09-24 |  |  |  |  |  |
| A1270 |  | Encofrado y Desencofrado en Pilotes | 9d | 2024-09-14 | 2024-09-22 | A1260 | 0d |  | Ingeniero Residente de Obra [72 h]; Ing. SSOMA [72 h]; Operario [72 h]; Peón [72 h]; Alambre Negro Recocido N° 08 [72 kg]; Clavos para Madera con Cabeza de 2 1/2" [72 kg]; Madera Tornillo [72 P2]; Herramientas Manuales [72 h] | 1,609.02 |
| A1280 |  | Concreto Para Pilotes F'c=28 Mpa | 2d | 2024-09-23 | 2024-09-24 | A1270 | 0d |  | Ingeniero Residente de Obra [16 h]; Ing. SSOMA [16 h]; Ing. Responsable de Calidad [16 h]; Operario [16 h]; Peón [16 h]; Concreto Premezclado F'c = 280 kg/cm2 [16 m3]; Herramientas Manuales [16 h]; Vibrador de Concreto 4 HP 1.25" [16 h] | 8,839.32 |
|  | 5 | **Carpinteria de Madera** |  | 2024-09-25 | 2024-10-31 |  |  |  |  |  |
| A1290 |  | Columna De Ø 8" | 7d | 2024-09-25 | 2024-10-01 | A1280 | 0d |  | Ingeniero Residente de Obra [56 h]; Ing. SSOMA [56 h]; Ing. Responsable de Calidad [56 h]; Operario [56 h]; Peón [56 h]; Madera Tornillo [56 P2]; Herramientas Manuales [56 h] | 626.5 |
| A1300 |  | Viga De 3"X10" | 10d | 2024-10-02 | 2024-10-11 | A1290 | 0d |  | Ingeniero Residente de Obra [80 h]; Ing. SSOMA [80 h]; Ing. Responsable de Calidad [80 h]; Operario [80 h]; Peón [80 h]; Madera Tornillo [80 P2]; Herramientas Manuales [80 h]; Andamio Metalico [80 h] | 1,695 |
| A1310 |  | Larguero De 2"X10" | 15d | 2024-10-12 | 2024-10-26 | A1300 | 0d |  | Ingeniero Residente de Obra [120 h]; Ing. SSOMA [120 h]; Operario [120 h]; Peón [120 h]; Madera Tornillo [120 P2]; Herramientas Manuales [120 h]; Andamio Metalico [120 h] | 2,542.5 |
| A1320 |  | Arriostres De 3"X8" | 15d | 2024-10-17 | 2024-10-31 | A1310 SS+5d | 0d |  | Ingeniero Residente de Obra [120 h]; Ing. SSOMA [120 h]; Operario [120 h]; Peón [120 h]; Madera Tornillo 3" x 8" [120 Unid]; Herramientas Manuales [120 h]; Andamio Metalico [120 h] | 6,022.5 |

| ID | WBS | Activity | Duration | Start | Finish | Predecessors | Total float | Resources | Cost |
| --- | --- | --- | --- | --- | --- | --- | --- | --- | --- |
|  | 6 | **Accesorios Metalicos** |  | 2024-10-17 | 2024-10-31 |  |  |  |  |
| A1330 |  | Perno Hexagonal 1/2"X17" + 2 Tuercas + 2 Arandelas | 15d | 2024-10-17 | 2024-10-31 | A1320 FF | 438d | Ingeniero Residente de Obra [120 h]; Ing. SSOMA [120 h]; Operario [120 h]; Perno Hexagonal 1/2" x 17" [120 Unid]; Arandela Plana de 1/2" [120 Unid]; Tuerca 1/2" [120 Unid]; Herramientas Manuales [120 h] | 1,743.3 |
| A1340 |  | Perno Hexagonal 5/8"X6" + 2 Tuercas + 2 Arandelas | 15d | 2024-10-17 | 2024-10-31 | A1320 FF | 438d | Ingeniero Residente de Obra [120 h]; Ing. SSOMA [120 h]; Operario [120 h]; Perno Hexagonal 5/8" x 6" [120 Unid]; Arandela Plana de 5/8" [120 Unid]; Tuerca 5/8" [120 Unid]; Herramientas Manuales [120 h] | 1,905.3 |
| A1350 |  | Perno Hexagonal 3/4"X16" + 2 Tuercas + 2 Arandelas | 15d | 2024-10-17 | 2024-10-31 | A1320 FF | 438d | Ingeniero Residente de Obra [120 h]; Ing. SSOMA [120 h]; Operario [120 h]; Perno Hexagonal 3/4" x 16" [120 Unid]; Arandela Plana de 3/4" [120 Unid]; Tuerca 3/4" [120 Unid]; Herramientas Manuales [120 h] | 1,671.3 |
| A1360 |  | Perno Hexagonal 1/2"X6.5" + 2 Tuercas + 2 Arandelas | 15d | 2024-10-17 | 2024-10-31 | A1320 FF | 0d | Ingeniero Residente de Obra [120 h]; Ing. SSOMA [120 h]; Operario [120 h]; Perno Hexagonal 1/2" x 6.5" [120 Unid]; Arandela Plana de 1/2" [120 Unid]; Tuerca 1/2" [120 Unid]; Herramientas Manuales [120 h] | 1,743.3 |
|  | 7 | **Varios** |  | 2024-11-01 | 2024-11-05 |  |  |  |  |
| A1370 |  | Limpieza Final de Obra | 5d | 2024-11-01 | 2024-11-05 | A1360 | 0d | Ingeniero Residente de Obra [40 h]; Ing. SSOMA [40 h]; Operario [40 h]; Peón [40 h]; Herramientas Manuales [40 h] | 207.5 |
|  | 8 | **Mantenimiento Post Plantación** |  | 2024-09-09 | 2025-12-30 |  |  |  |  |
|  | 1 | **Mantenimiento de Vegetación Arborea** |  | 2024-09-09 | 2025-12-30 |  |  |  |  |
| A2320 |  | Recalce | 365d | 2024-09-09 | 2025-09-08 | A1070 | 126d |  |  |
| A2290 |  | Deshierbe | 463d | 2024-09-24 | 2025-12-30 | A1070 SS+30d | 13d |  |  |
| A2300 |  | Control de Plagas | 365d | 2024-12-17 | 2025-12-16 | A1070 FS+99d | 27d |  |  |
| A2310 |  | Poda | 365d | 2024-12-17 | 2025-12-16 | A1070 FS+99d | 27d |  |  |
|  | 2 | **Mantenimiento de Vegetación Arbustiva** |  | 2024-09-09 | 2025-03-07 |  |  |  |  |
| A2240 |  | Deshierne | 180d | 2024-09-09 | 2025-03-07 | A1070 | 311d |  |  |
| A2250 |  | Recalce | 180d | 2024-09-09 | 2025-03-07 | A1070 | 311d |  |  |
|  | 3 | **Bioestimulación** |  | 2024-12-17 | 2025-06-14 |  |  |  |  |
| A2330 |  | Aplicación de Enraizante | 180d | 2024-12-17 | 2025-06-14 | A1070 FS+99d | 212d |  |  |
|  | 4 | **Fertilización Quimica** |  | 2024-10-24 | 2025-04-21 |  |  |  |  |
| A2340 |  | Fertilización de liberación lenta NPK | 180d | 2024-10-24 | 2025-04-21 | A1100 | 266d |  |  |
| A2350 |  | Aplicación Foliar bioestimulantes | 180d | 2024-10-24 | 2025-04-21 | A1100 | 266d |  |  |
|  | 5 | **Aplicación de Micorrizas** |  | 2024-10-24 | 2024-11-22 |  |  |  |  |
| A2360 |  | Aplicación de Micorrizas | 30d | 2024-10-24 | 2024-11-22 | A1100 | 416d |  |  |
|  | 6 | **Monitoreo de Plantaciones** |  | 2024-09-24 | 2025-09-23 |  |  |  |  |
| A2370 |  | Monitoreo de Plantaciones | 365d | 2024-09-24 | 2025-09-23 | A1070 SS+30d | 111d |  |  |

| ID | WBS | Activity | Duration | Start | Finish | Predecessors | Total float | Resources | Cost |
| --- | --- | --- | --- | --- | --- | --- | --- | --- | --- |
|  | 2 | **Infraestructura Verde y Paisajismo - Paquete 02 - Parte 01** |  | 2024-08-11 | 2025-12-31 |  |  |  |  |
|  | 1 | **Revegetación / Reforestación De La Ribera** |  | 2024-08-11 | 2025-03-16 |  |  |  |  |
|  | 1 | **Preparación Del Terreno** |  | 2024-11-06 | 2025-02-24 |  |  |  |  |
| A1380 |  | Ubicación Y Delimitación De La Zona De Trabajo | 5d | 2024-11-06 | 2024-11-10 | A1370 | 0d | Ingeniero Residente de Obra [40 h]; Ing. SSOMA [40 h]; Operario [40 h]; Peón [40 h]; Concreto Ciclopeo [40 m3]; Parantes de Madsera de 1 1/2 x 1 1/2" [40 Unid]; Cinta de Señalización de Peligro [40 Unid] | 2,635.5 |
| A1390 |  | Trazado, Marcación Y Estacado | 5d | 2024-11-06 | 2024-11-10 | A1380 SS | 428d | Ingeniero Residente de Obra [40 h]; Ing. SSOMA [40 h]; Operario [40 h]; Peón [40 h]; Jefe de Topografia [40 h]; Yeso [40 kg]; Estacas de Madera [40 Unid]; Cordel [40 m]; Estación Total [40 h]; Nivel Topografico [40 h]; Herramientas Manuales [40 h] | 1,875.5 |
| A1400 |  | Limpieza Y Desbroce Del Terreno Con Medios Manuales | 5d | 2024-11-06 | 2024-11-10 | A1380 SS | 0d | Ingeniero Residente de Obra [40 h]; Ing. SSOMA [40 h]; Operario [40 h]; Peón [40 h]; Herramientas Manuales [40 h] | 207.5 |
| A1410 |  | Eliminación De Materiales De Desbroce (Incluye Transporte) | 4d | 2024-11-11 | 2024-11-14 | A1400 | 0d | Ingeniero Residente de Obra [32 h]; Ing. SSOMA [32 h]; Operario [32 h]; Peón [32 h]; Herramientas Manuales [32 h]; Retroexcavadora Case 590 SK [32 h]; Camión Volquete de 15 m3 [32 h] | 11,222 |
| A1420 |  | Despedregado Del Terreno Con Medios Manuales | 12d | 2024-11-15 | 2024-11-26 | A1410 | 0d | Ingeniero Residente de Obra [96 h]; Ing. SSOMA [96 h]; Peón [96 h]; Herramientas Manuales [96 h] | 207.36 |
| A1430 |  | Preparación Y Aporte Del Sustrato | 90d | 2024-11-27 | 2025-02-24 | A1420 | 0d | Ingeniero Residente de Obra [720 h]; Ing. SSOMA [720 h]; Ing. Responsable de Calidad [720 h]; Operario [720 h]; Peón [720 h]; Sustrato [720 m3]; Herramientas Manuales [720 h]; Zaranda [720 h] | 50,326.2 |
| A1440 |  | Riego De Áreas Vegetadas Con Camión Cisterna | 90d | 2024-11-27 | 2025-02-24 | A1430 SS | 322d | Ingeniero Residente de Obra [720 h]; Ing. SSOMA [720 h]; Operario [720 h]; Camión Cisterna (2,500 GLNS.) [720 h] | 117,379.8 |
|  | 2 | **Especies Arbustivas** |  | 2024-12-02 | 2025-01-20 |  |  |  |  |
| A1450 |  | Tessaria Integrifolia (Pájaro Bobo) Incluye Siembra Y Transporte | 25d | 2024-12-02 | 2024-12-26 | A1430 SS+5d | 0d | Ingeniero Residente de Obra [200 h]; Ing. SSOMA [200 h]; Ing. Responsable de Calidad [200 h]; Operario [200 h]; Peón [200 h]; Tessaria Integrifolia (Pajaro Bobo) [200 Unid]; Herramientas Manuales [200 h] | 4,037.5 |
| A1460 |  | Baccharis Latifolia (Chilco) Incluye Siembra Y Transporte | 25d | 2024-12-27 | 2025-01-20 | A1450 | 0d | Ingeniero Residente de Obra [200 h]; Ing. SSOMA [200 h]; Ing. Responsable de Calidad [200 h]; Operario [200 h]; Peón [200 h]; Baccharis Latifolia (Chilco) [200 Unid]; Herramientas Manuales [200 h] | 4,037.5 |
|  | 3 | **Especies Arbóreas** |  | 2025-01-21 | 2025-03-16 |  |  |  |  |
| A1470 |  | Schinus Molle (Molle) Incluye Siembra Y Transporte | 20d | 2025-01-21 | 2025-02-09 | A1460 | 0d | Ingeniero Residente de Obra [160 h]; Ing. SSOMA [160 h]; Ing. Responsable de Calidad [160 h]; Operario [160 h]; Peón [160 h]; Schinus Molle (Molle) [160 Unid]; Herramientas Manuales [160 h] | 4,430 |
| A1480 |  | Acacia Macracantha (Huarango) Incluye Siembra Y Transporte | 20d | 2025-02-10 | 2025-03-01 | A1470 | 0d | Ingeniero Residente de Obra [160 h]; Ing. SSOMA [160 h]; Ing. Responsable de Calidad [160 h]; Operario [160 h]; Peón [160 h]; Acacia Macracantha (Huarango) [160 Unid]; Herramientas Manuales [160 h] | 4,430 |
| A1490 |  | Salix Humboldtiana (Sauce) Incluye Siembra Y Transporte | 15d | 2025-03-02 | 2025-03-16 | A1480 | 0d | Ingeniero Residente de Obra [120 h]; Ing. SSOMA [120 h]; Ing. Responsable de Calidad [120 h]; Operario [120 h]; Peón [120 h]; Salix Humboldtina (Sauce) [120 Unid]; Herramientas Manuales [120 h] | 4,222.5 |
|  | 4 | **Vivero Temporal** |  | 2024-08-11 | 2024-08-17 |  |  |  |  |
| A1500 |  | Implementación De Vivero Temporal | 7d | 2024-08-11 | 2024-08-17 | A1000 SS+3d | 513d | Herramientas Manuales [728 h]; Ingeniero Residente de Obra [728 h]; Ing. SSOMA [728 h]; Peón [728 h]; Alambre Negro Recocido N° 16 [728 kg]; Clavos para Madera con Cabeza de 2 1/2" [728 kg]; Malla Rashel [728 m]; Madera de Eucalipto [728 Unid] | 24,641.89 |
|  | 5 | **Mantenimiento Post Plantación** |  | 2024-12-27 | 2025-12-31 |  |  |  |  |
|  | 2 | **Mantenimiento de Vegetación Arbolea** |  | 2024-12-27 | 2025-12-31 |  |  |  |  |
| A2450 |  | Recalce | 269d | 2024-12-27 | 2025-09-21 | A1450 | 113d |  |  |
| A2420 |  | Deshierbe | 365d | 2025-01-01 | 2025-12-31 | A1450 SS+30d | 12d |  |  |
| A2430 |  | Control de Plagas | 269d | 2025-04-05 | 2025-12-29 | A1450 FS+99d | 14d |  |  |
| A2440 |  | Poda | 269d | 2025-04-05 | 2025-12-29 | A1450 FS+99d | 14d |  |  |

| ID | WBS | Activity | Duration | Start | Finish | Predecessors | Total float | Resources | Cost |
| --- | --- | --- | --- | --- | --- | --- | --- | --- | --- |
|  | 1 | **Mantenimiento de Vegetación Arbustiva** |  | 2024-12-27 | 2025-03-18 |  |  |  |  |
| A2380 |  | Deshierbe | 82d | 2024-12-27 | 2025-03-18 | A1450 | 300d |  |  |
| A2410 |  | Recalce | 82d | 2024-12-27 | 2025-03-18 | A1450 | 300d |  |  |
|  | 3 | **Bioestimulación** |  | 2025-04-05 | 2025-06-25 |  |  |  |  |
| A2460 |  | Aplicación de Enraizante | 82d | 2025-04-05 | 2025-06-25 | A1450 FS+99d | 201d |  |  |
|  | 5 | **Fertilización Quimica** |  | 2025-03-17 | 2025-06-06 |  |  |  |  |
| A2470 |  | Fertilización de liberación lenta NPK | 82d | 2025-03-17 | 2025-06-06 | A1490 | 220d |  |  |
| A2480 |  | Aplicación Foliar Bioestimulantes | 82d | 2025-03-17 | 2025-06-06 | A1490 | 220d |  |  |
|  | 6 | **Aplicación de Micorrizas** |  | 2025-03-17 | 2025-04-15 |  |  |  |  |
| A2490 |  | Aplicación de Micorrizas | 30d | 2025-03-17 | 2025-04-15 | A1490 | 272d |  |  |
|  | 7 | **Monitoreo de Plantaciones** |  | 2025-01-01 | 2025-09-26 |  |  |  |  |
| A2500 |  | Monitoreo de Plantaciones | 269d | 2025-01-01 | 2025-09-26 | A1450 SS+30d | 108d |  |  |
|  | 3 | **Infraestructura Verde y Paisajismo - Paquete 02 - Parte 02** |  | 2025-03-17 | 2026-01-12 |  |  |  |  |
|  | 1 | **Revegetación / Reforestación De La Ribera** |  | 2025-03-17 | 2025-06-17 |  |  |  |  |
|  | 1 | **Preparación Del Terreno** |  | 2025-03-17 | 2025-06-17 |  |  |  |  |
| A1510 |  | Ubicación Y Delimitación De La Zona De Trabajo | 5d | 2025-03-17 | 2025-03-21 | A1490 | 0d | Ingeniero Residente de Obra [40 h]; Ing. SSOMA [40 h]; Operario [40 h]; Peón [40 h]; Concreto Ciclopeo [40 m3]; Parantes de Madsera de 1 1/2 x 1 1/2" [40 Unid]; Cinta de Señalización de Peligro [40 Unid] | 2,635.5 |
| A1520 |  | Trazado, Marcación Y Estacado | 5d | 2025-03-17 | 2025-03-21 | A1510 SS | 297d | Ingeniero Residente de Obra [40 h]; Ing. SSOMA [40 h]; Jefe de Topografia [40 h]; Operario [40 h]; Peón [40 h]; Yeso [40 kg]; Estacas de Madera [40 Unid]; Cordel [40 m]; Estación Total [40 h]; Nivel Topografico [40 h]; Herramientas Manuales [40 h] | 1,875.5 |
| A1530 |  | Limpieza Y Desbroce Del Terreno Con Medios Manuales | 5d | 2025-03-17 | 2025-03-21 | A1510 SS | 0d | Herramientas Manuales [40 h]; Ingeniero Residente de Obra [40 h]; Ing. SSOMA [40 h]; Operario [40 h]; Peón [40 h] | 207.5 |
| A1550 |  | Despedregado Del Terreno Con Medios Manuales | 2d | 2025-03-18 | 2025-03-19 | A1530 SS+1d | 0d | Ingeniero Residente de Obra [16 h]; Ing. SSOMA [16 h]; Peón [16 h]; Herramientas Manuales [16 h] | 34.56 |
| A1560 |  | Preparación Y Aporte Del Sustrato | 40d | 2025-03-20 | 2025-04-28 | A1550 | 0d | Herramientas Manuales [320 h]; Ingeniero Residente de Obra [320 h]; Ing. SSOMA [320 h]; Ing. Responsable de Calidad [320 h]; Sustrato [320 m3]; Zaranda [320 h] | 20,707.2 |
| A1570 |  | Riego De Áreas Vegetadas Con Camión Cisterna | 90d | 2025-03-20 | 2025-06-17 | A1560 SS | 209d | Ingeniero Residente de Obra [720 h]; Ing. SSOMA [720 h]; Operario [720 h]; Camión Cisterna (2,500 GLNS.) [720 h] | 117,379.8 |
| A1540 |  | Eliminación De Materiales De Desbroce (Incluye Transporte) | 2d | 2025-03-22 | 2025-03-23 | A1530 | 295d | Ing. SSOMA [16 h]; Ingeniero Residente de Obra [16 h]; Operario [16 h]; Peón [16 h]; Herramientas Manuales [16 h]; Retroexcavadora Case 590 SK [16 h]; Camión Volquete de 15 m3 [16 h] | 5,611 |
|  | 2 | **Especies Arbóreas** |  | 2025-03-25 | 2025-05-17 |  |  |  |  |
| A1580 |  | Schinus Molle (Molle) Incluye Siembra Y Transporte | 18d | 2025-03-25 | 2025-04-11 | A1560 SS+5d | 0d | Ingeniero Residente de Obra [144 h]; Ing. SSOMA [144 h]; Ing. Responsable de Calidad [144 h]; Operario [144 h]; Peón [144 h]; Schinus Molle (Molle) [144 Unid]; Herramientas Manuales [144 h] | 3,987 |
| A1590 |  | Acacia Macracantha (Huarango) Incluye Siembra Y Transporte | 18d | 2025-04-12 | 2025-04-29 | A1580 | 0d | Herramientas Manuales [144 h]; Ingeniero Residente de Obra [144 h]; Ing. SSOMA [144 h]; Ing. Responsable de Calidad [144 h]; Operario [144 h]; Peón [144 h]; Acacia Macracantha (Huarango) [144 Unid] | 3,987 |
| A1600 |  | Salix Humboldtiana (Sauce) Incluye Siembra Y Transporte | 18d | 2025-04-30 | 2025-05-17 | A1590 | 0d | Ingeniero Residente de Obra [144 h]; Ing. SSOMA [144 h]; Ing. Responsable de Calidad [144 h]; Operario [144 h]; Peón [144 h]; Salix Humboldtina (Sauce) [144 Unid]; Herramientas Manuales [144 h] | 5,067 |

| ID | WBS | Activity | Duration | Start | Finish | Predecessors | Total float | Resources | Cost |
| --- | --- | --- | --- | --- | --- | --- | --- | --- | --- |
|  | 3 | **Mantenimiento Post Plantación** |  | 2025-04-12 | 2026-01-12 |  |  |  |  |
|  | 1 | **Mantenimienot de Vegetación Arborea** |  | 2025-04-12 | 2026-01-12 |  |  |  |  |
| A2540 |  | Recalce | 195d | 2025-04-12 | 2025-10-23 | A1580 | 81d |  |  |
| A2510 |  | Deshierbe | 264d | 2025-04-24 | 2026-01-12 | A1580 SS+30d | 0d |  |  |
| A2520 |  | Control | 195d | 2025-07-02 | 2026-01-12 | A1580 SS+99d | 0d |  |  |
| A2530 |  | Poda | 195d | 2025-07-02 | 2026-01-12 | A1580 SS+99d | 0d |  |  |
|  | 3 | **Mantenimienot de Vegetación Arbustiva** |  | 2025-07-20 | 2026-01-12 |  |  |  |  |
| A2550 |  | Deshierve | 177d | 2025-07-20 | 2026-01-12 | A1580 FS+99d | 0d |  |  |
| A2560 |  | Recalce | 177d | 2025-07-20 | 2026-01-12 | A1580 FS+99d | 0d |  |  |
|  | 2 | **Bioestimulación** |  | 2025-07-20 | 2026-01-12 |  |  |  |  |
| A2570 |  | Aplicación de Enraizante | 177d | 2025-07-20 | 2026-01-12 | A1580 FS+99d | 0d |  |  |
|  | 4 | **Fertilización Quimica** |  | 2025-05-18 | 2025-11-10 |  |  |  |  |
| A2580 |  | Fertilización de líberación lenta NPK | 177d | 2025-05-18 | 2025-11-10 | A1600 | 63d |  |  |
| A2590 |  | Apliación Foliar Bioestimulantes | 177d | 2025-05-18 | 2025-11-10 | A1600 | 63d |  |  |
|  | 5 | **Aplicación de Micorrizas** |  | 2025-05-18 | 2025-06-16 |  |  |  |  |
| A2600 |  | Apliación de Micorrizas | 30d | 2025-05-18 | 2025-06-16 | A1600 | 210d |  |  |
|  | 6 | **Monitoreo de Plantaciones** |  | 2025-04-24 | 2026-01-12 |  |  |  |  |
| A2610 |  | Monitoreo de Plantaciones | 264d | 2025-04-24 | 2026-01-12 | A1580 SS+30d | 0d |  |  |
|  | 4 | **Infraestructura Verde y Paisajismo - Paquete 03** |  | 2025-05-18 | 2026-01-12 |  |  |  |  |
|  | 1 | **Revegetación / Reforestación De La Ribera** |  | 2025-05-18 | 2025-08-24 |  |  |  |  |
|  | 1 | **Preparación Del Terreno** |  | 2025-05-18 | 2025-08-24 |  |  |  |  |
| A1610 |  | Ubicación Y Delimitación De La Zona De Trabajo | 5d | 2025-05-18 | 2025-05-22 | A1600 | 0d | Ingeniero Residente de Obra [40 h]; Ing. SSOMA [40 h]; Operario [40 h]; Peón [40 h]; Concreto Ciclopeo [40 m3]; Parantes de Madsera de 1 1/2 x 1 1/2" [40 Unid]; Cinta de Señalización de Peligro [40 Unid] | 2,635.5 |
| A1620 |  | Trazado, Marcación Y Estacado | 5d | 2025-05-18 | 2025-05-22 | A1610 SS | 235d | Ingeniero Residente de Obra [40 h]; Ing. SSOMA [40 h]; Jefe de Topografia [40 h]; Nivel Topografico [40 h]; Operario [40 h]; Peón [40 h]; Yeso [40 kg]; Estacas de Madera [40 Unid]; Cordel [40 m]; Estación Total [40 h]; Herramientas Manuales [40 h] | 1,875.5 |
| A1630 |  | Limpieza Y Desbroce Del Terreno Con Medios Manuales | 5d | 2025-05-18 | 2025-05-22 | A1610 SS | 0d | Ingeniero Residente de Obra [40 h]; Ing. SSOMA [40 h]; Operario [40 h]; Peón [40 h]; Herramientas Manuales [40 h] | 207.5 |
| A1650 |  | Despedregado Del Terreno Con Medios Manuales | 8d | 2025-05-19 | 2025-05-26 | A1630 SS+1d | 0d | Ingeniero Residente de Obra [64 h]; Ing. SSOMA [64 h]; Peón [64 h]; Herramientas Manuales [64 h] | 138.24 |
| A1640 |  | Eliminación De Materiales De Desbroce (Incluye Transporte) | 3d | 2025-05-23 | 2025-05-25 | A1630 | 232d | Herramientas Manuales [24 h]; Ingeniero Residente de Obra [24 h]; Ing. SSOMA [24 h]; Operario [24 h]; Peón [24 h]; Retroexcavadora Case 590 SK [24 h]; Camión Volquete de 15 m3 [24 h] | 8,416.5 |
| A1680 |  | Preparación Y Aporte Del Sustrato | 60d | 2025-05-27 | 2025-07-25 | A1650 | 0d | Ingeniero Residente de Obra [480 h]; Ing. SSOMA [480 h]; Sustrato [480 m3]; Herramientas Manuales [480 h]; Zaranda [480 h] | 31,060.8 |
| A1690 |  | Riego De Áreas Vegetadas Con Camión Cisterna | 90d | 2025-05-27 | 2025-08-24 | A1680 SS | 141d | Ingeniero Residente de Obra [720 h]; Ing. SSOMA [720 h]; Operario [720 h]; Camión Cisterna (2,500 GLNS.) [720 h] | 117,379.8 |

| ID | WBS | Activity | Duration | Start | Finish | Predecessors | Total float | Resources | Cost |
| --- | --- | --- | --- | --- | --- | --- | --- | --- | --- |
|  | 2 | **Especies Arbustivas** |  | 2025-06-01 | 2025-06-20 |  |  |  |  |
| A1700 |  | Tessaria Integrifolia (Pájaro Bobo) Incluye Siembra Y Transporte | 10d | 2025-06-01 | 2025-06-10 | A1680 SS+5d | 0d | Ingeniero Residente de Obra [80 h]; Ing. SSOMA [80 h]; Ing. Responsable de Calidad [80 h]; Operario [80 h]; Peón [80 h]; Tessaria Integrifolia (Pajaro Bobo) [80 Unid]; Herramientas Manuales [80 h] | 1,615 |
| A1710 |  | Baccharis Latifolia (Chilco) Incluye Siembra Y Transporte | 10d | 2025-06-11 | 2025-06-20 | A1700 | 0d | Herramientas Manuales [80 h]; Ingeniero Residente de Obra [80 h]; Ing. SSOMA [80 h]; Ing. Responsable de Calidad [80 h]; Operario [80 h]; Peón [80 h]; Baccharis Latifolia (Chilco) [80 Unid] | 1,615 |
|  | 3 | **Especies Arbóreas** |  | 2025-06-21 | 2025-08-04 |  |  |  |  |
| A1720 |  | Schinus Molle (Molle) Incluye Siembra Y Transporte | 20d | 2025-06-21 | 2025-07-10 | A1710 | 0d | Ingeniero Residente de Obra [160 h]; Ing. SSOMA [160 h]; Ing. Responsable de Calidad [160 h]; Operario [160 h]; Peón [160 h]; Schinus Molle (Molle) [160 Unid]; Herramientas Manuales [160 h] | 4,430 |
| A1730 |  | Acacia Macracantha (Huarango) Incluye Siembra Y Transporte | 20d | 2025-07-11 | 2025-07-30 | A1720 | 0d | Herramientas Manuales [160 h]; Ingeniero Residente de Obra [160 h]; Ing. SSOMA [160 h]; Ing. Responsable de Calidad [160 h]; Operario [160 h]; Peón [160 h]; Acacia Macracantha (Huarango) [160 Unid] | 4,430 |
| A1740 |  | Salix Humboldtiana (Sauce) Incluye Siembra Y Transporte | 5d | 2025-07-31 | 2025-08-04 | A1730 | 0d | Ingeniero Residente de Obra [40 h]; Ing. SSOMA [40 h]; Ing. Responsable de Calidad [40 h]; Operario [40 h]; Peón [40 h]; Salix Humboldtina (Sauce) [40 Unid]; Herramientas Manuales [40 h] | 1,407.5 |
|  | 4 | **Mantenimiento Post Plantación** |  | 2025-06-11 | 2026-01-12 |  |  |  |  |
|  | 1 | **Mantenimiento de Vegetación Arborea** |  | 2025-07-01 | 2026-01-12 |  |  |  |  |
| A2620 |  | Deshierbe | 196d | 2025-07-01 | 2026-01-12 | A1700 SS+30d | 0d |  |  |
| A2630 |  | Control de Plagas | 117d | 2025-09-18 | 2026-01-12 | A1700 FS+99d | 0d |  |  |
| A2640 |  | Poda | 117d | 2025-09-18 | 2026-01-12 | A1700 FS+99d | 0d |  |  |
| A2650 |  | Recalce | 117d | 2025-09-18 | 2026-01-12 | A1700 FS+99d | 0d |  |  |
|  | 2 | **Mantenimiento de Vegetación Arbustiva** |  | 2025-06-11 | 2025-07-29 |  |  |  |  |
| A2660 |  | Deshierva | 49d | 2025-06-11 | 2025-07-29 | A1700 | 167d |  |  |
| A2670 |  | Recalce | 49d | 2025-06-11 | 2025-07-29 | A1700 | 167d |  |  |
|  | 3 | **Bioestimulación** |  | 2025-09-18 | 2025-11-05 |  |  |  |  |
| A2680 |  | Aplicación de Enraizante | 49d | 2025-09-18 | 2025-11-05 | A1700 FS+99d | 68d |  |  |
|  | 4 | **Fertilización Quimica** |  | 2025-08-05 | 2025-09-22 |  |  |  |  |
| A2690 |  | Fertilización de liberación lenta NPK | 49d | 2025-08-05 | 2025-09-22 | A1740 | 112d |  |  |
| A2700 |  | Aplicación Foliar bioestimulantes | 49d | 2025-08-05 | 2025-09-22 | A1740 | 112d |  |  |
|  | 5 | **Aplicación de Micorrizas** |  | 2025-08-05 | 2025-09-03 |  |  |  |  |
| A2710 |  | Aplicación de Micorrizas | 30d | 2025-08-05 | 2025-09-03 | A1740 | 131d |  |  |
|  | 6 | **Monitoreo de Plantaciones** |  | 2025-07-01 | 2026-01-12 |  |  |  |  |
| A2720 |  | Monitoreo de Plantaciones | 196d | 2025-07-01 | 2026-01-12 | A1700 SS+30d | 0d |  |  |

| ID | WBS | Activity | Duration | Start | Finish | Predecessors | Total float | Free float | Resources | Cost |
| --- | --- | --- | --- | --- | --- | --- | --- | --- | --- | --- |
|  | 5 | **Infraestructura Verde y Paisajismo - Paquete 04** |  | 2025-08-05 | 2026-01-12 |  |  |  |  |  |
|  | 1 | **Revegetación / Reforestación De La Ribera** |  | 2025-08-05 | 2026-01-12 |  |  |  |  |  |
|  | 1 | **Preparación Del Terreno** |  | 2025-08-05 | 2026-01-12 |  |  |  |  |  |
| A1750 |  | Ubicación Y Delimitación De La Zona De Trabajo | 5d | 2025-08-05 | 2025-08-09 | A1740 | 0d |  | Ingeniero Residente de Obra [40 h]; Ing. SSOMA [40 h]; Operario [40 h]; Peón [40 h]; Concreto Ciclopeo [40 m3]; Parantes de Madsera de 1 1/2 x 1 1/2" [40 Unid]; Cinta de Señalización de Peligro [40 Unid] | 2,635.5 |
| A1760 |  | Trazado, Marcación Y Estacado | 5d | 2025-08-05 | 2025-08-09 | A1750 SS | 156d |  | Ingeniero Residente de Obra [40 h]; Ing. SSOMA [40 h]; Ing. Responsable de Calidad [40 h]; Jefe de Topografia [40 h]; Operario [40 h]; Peón [40 h]; Yeso [40 kg]; Estacas de Madera [40 Unid]; Cordel [40 m]; Estación Total [40 h]; Nivel Topografico [40 h]; Herramientas Manuales [40 h] | 1,875.5 |
| A1770 |  | Limpieza Y Desbroce Del Terreno Con Medios Manuales | 5d | 2025-08-05 | 2025-08-09 | A1750 SS | 0d |  | Herramientas Manuales [40 h]; Ingeniero Residente de Obra [40 h]; Ing. SSOMA [40 h]; Operario [40 h]; Peón [40 h] | 207.5 |
| A1790 |  | Despedregado Del Terreno Con Medios Manuales | 5d | 2025-08-06 | 2025-08-10 | A1770 SS+1d | 0d |  | Ingeniero Residente de Obra [40 h]; Ing. SSOMA [40 h]; Peón [40 h]; Herramientas Manuales [40 h] | 86.4 |
| A1780 |  | Eliminación De Materiales De Desbroce (Incluye Transporte) | 3d | 2025-08-10 | 2025-08-12 | A1770 | 153d |  | Herramientas Manuales [24 h]; Ingeniero Residente de Obra [24 h]; Ing. SSOMA [24 h]; Operario [24 h]; Peón [24 h]; Retroexcavadora Case 590 SK [24 h]; Camión Volquete de 15 m3 [24 h] | 8,416.5 |
| A1800 |  | Preparación Y Aporte Del Sustrato | 65d | 2025-08-11 | 2025-10-14 | A1790 | 0d |  | Ingeniero Residente de Obra [520 h]; Ing. SSOMA [520 h]; Ing. Responsable de Calidad [520 h]; Operario [520 h]; Peón [520 h]; Sustrato [520 m3]; Herramientas Manuales [520 h]; Zaranda [520 h] | 36,346.7 |
| A1820 |  | Tala De Árbol Con Medio Mecánico | 3d | 2025-08-11 | 2025-08-13 | A1790 | 145d | 0d | Ingeniero Residente de Obra [24 h]; Ing. SSOMA [24 h]; Operario [24 h]; Peón [24 h]; Herramientas Manuales [24 h]; Motosierra [24 h] | 465.3 |
| A1830 |  | Especies Arbóreas A Compensar | 7d | 2025-08-14 | 2025-08-20 | A1820 | 145d |  | Ingeniero Residente de Obra [56 h]; Ing. SSOMA [56 h]; Ing. Responsable de Calidad [56 h]; Operario [56 h]; Peón [56 h]; Especies Arbóreas [56 Unid]; Herramientas Manuales [56 h] | 1,410.5 |
| A1810 |  | Riego De Áreas Vegetadas Con Camión Cisterna | 90d | 2025-10-15 | 2026-01-12 | A1800 | 0d |  | Ingeniero Residente de Obra [720 h]; Ing. SSOMA [720 h]; Operario [720 h]; Camión Cisterna (2,500 GLNS.) [720 h] | 117,379.8 |
|  | 2 | **Especies Arbóreas** |  | 2025-08-16 | 2025-09-09 |  |  |  |  |  |
| A1840 |  | Schinus Molle (Molle) Incluye Siembra Y Transporte | 10d | 2025-08-16 | 2025-08-25 | A1800 SS+5d | 125d | 0d | Herramientas Manuales [80 h]; Ingeniero Residente de Obra [80 h]; Ing. SSOMA [80 h]; Ing. Responsable de Calidad [80 h]; Operario [80 h]; Peón [80 h]; Schinus Molle (Molle) [80 Unid] | 2,215 |
| A1850 |  | Acacia Macracantha (Huarango) Incluye Siembra Y Transporte | 10d | 2025-08-26 | 2025-09-04 | A1840 | 125d | 0d | Ingeniero Residente de Obra [80 h]; Ing. SSOMA [80 h]; Ing. Responsable de Calidad [80 h]; Operario [80 h]; Peón [80 h]; Herramientas Manuales [80 h]; Acacia Macracantha (Huarango) [80 Unid] | 2,215 |
| A1860 |  | Salix Humboldtiana (Sauce) Incluye Siembra Y Transporte | 5d | 2025-09-05 | 2025-09-09 | A1850 | 125d |  | Ingeniero Residente de Obra [40 h]; Ing. SSOMA [40 h]; Ing. Responsable de Calidad [40 h]; Operario [40 h]; Peón [40 h]; Salix Humboldtina (Sauce) [40 Unid]; Herramientas Manuales [40 h] | 1,407.5 |
|  | 3 | **Espacio Público Próximo A Bocatoma Fortaleza** |  | 2025-08-20 | 2025-11-25 |  |  |  |  |  |
|  | 1 | **Preparación Del Terreno** |  | 2025-08-20 | 2025-11-25 |  |  |  |  |  |
| A1870 |  | Ubicación Y Delimitación De La Zona De Trabajo | 5d | 2025-08-20 | 2025-08-24 | A1750 SS+15d | 0d |  | Ingeniero Residente de Obra [40 h]; Ing. SSOMA [40 h]; Operario [40 h]; Peón [40 h]; Concreto Ciclopeo [40 m3]; Parantes de Madsera de 1 1/2 x 1 1/2" [40 Unid]; Cinta de Señalización de Peligro [40 Unid] | 2,635.5 |
| A1880 |  | Trazado, Marcación Y Estacado | 5d | 2025-08-20 | 2025-08-24 | A1870 SS | 141d |  | Ingeniero Residente de Obra [40 h]; Ing. SSOMA [40 h]; Jefe de Topografia [40 h]; Operario [40 h]; Peón [40 h]; Yeso [40 kg]; Estacas de Madera [40 Unid]; Cordel [40 m]; Estación Total [40 h]; Nivel Topografico [40 h]; Herramientas Manuales [40 h] | 1,875.5 |
| A1890 |  | Limpieza Y Desbroce Del Terreno Con Medios Manuales | 5d | 2025-08-20 | 2025-08-24 | A1870 SS | 0d |  | Herramientas Manuales [40 h]; Ingeniero Residente de Obra [40 h]; Ing. SSOMA [40 h]; Operario [40 h]; Peón [40 h] | 207.5 |
| A1910 |  | Remoción Del Terreno Con Medios Manuales Con Profundidad Hasta 25 Cm | 3d | 2025-08-24 | 2025-08-26 | A1900 FF | 0d |  | Ingeniero Residente de Obra [24 h]; Ing. SSOMA [24 h]; Operario [24 h]; Peón [24 h]; Herramientas Manuales [24 h] | 124.5 |
| A1900 |  | Eliminación De Materiales De Desbroce (Incluye Transporte) | 2d | 2025-08-25 | 2025-08-26 | A1890 | 0d |  | Ingeniero Residente de Obra [16 h]; Ing. SSOMA [16 h]; Operario [16 h]; Peón [16 h]; Herramientas Manuales [16 h]; Retroexcavadora Case 590 SK [16 h]; Camión Volquete de 15 m3 [16 h] | 5,611 |
| A1920 |  | Rastrillado Del Terreno | 3d | 2025-08-25 | 2025-08-27 | A1910 SS+1d | 0d |  | Herramientas Manuales [24 h]; Ingeniero Residente de Obra [24 h]; Ing. SSOMA [24 h]; Peón [24 h] | 51.84 |
| A1930 |  | Preparación Y Aporte Del Sustrato | 20d | 2025-08-28 | 2025-09-16 | A1920 | 0d |  | Ingeniero Residente de Obra [160 h]; Ing. SSOMA [160 h]; Ing. Responsable de Calidad [160 h]; Operario [160 h]; Peón [160 h]; Sustrato [160 m3]; Herramientas Manuales [160 h]; Zaranda [160 h] | 11,183.6 |
| A1940 |  | Riego De Áreas Vegetadas Con Camión Cisterna | 90d | 2025-08-28 | 2025-11-25 | A1930 SS | 48d |  | Ingeniero Residente de Obra [720 h]; Ing. SSOMA [720 h]; Operario [720 h]; Peón [720 h]; Camión Cisterna (2,500 GLNS.) [720 h] | 118,935 |

| ID | WBS | Activity | Duration | Start | Finish | Predecessors | Total float | Free float | Resources | Cost |
| --- | --- | --- | --- | --- | --- | --- | --- | --- | --- | --- |
|  | 2 | **Especies Arbustivas** |  | 2025-09-02 | 2025-09-05 |  |  |  |  |  |
| A1950 |  | Galvezia Fruticosa (Galvezia). Incluye Siembra Y Transporte | 2d | 2025-09-02 | 2025-09-03 | A1930 SS+5d | 0d |  | Ingeniero Residente de Obra [16 h]; Ing. SSOMA [16 h]; Ing. Responsable de Calidad [16 h]; Operario [16 h]; Peón [16 h]; Galvezia Fruticosa (Galvezia) [16 Unid]; Herramientas Manuales [16 h] | 323 |
| A1960 |  | Bougainvillea Peruviana (Buganvilla). Incluye Siembra Y Transporte | 2d | 2025-09-04 | 2025-09-05 | A1950 | 0d |  | Herramientas Manuales [16 h]; Peón [16 h]; Operario [16 h]; Bougainvellea Peruviana (Buganvilla) [16 Unid]; Ingeniero Residente de Obra [16 h]; Ing. SSOMA [16 h]; Ing. Responsable de Calidad [16 h] | 323 |
|  | 3 | **Especies Arbóreas** |  | 2025-09-06 | 2025-09-07 |  |  |  |  |  |
| A1970 |  | Schinus Molle (Molle) Incluye Siembra Y Transporte | 1d | 2025-09-06 | 2025-09-06 | A1960 | 0d |  | Ing. Responsable de Calidad [8 h]; Ingeniero Residente de Obra [8 h]; Ing. SSOMA [8 h]; Operario [8 h]; Peón [8 h]; Schinus Molle (Molle) [8 Unid]; Herramientas Manuales [8 h] | 221.5 |
| A1980 |  | Acacia Macracantha (Huarango) Incluye Siembra Y Transporte | 1d | 2025-09-07 | 2025-09-07 | A1970 | 0d |  | Herramientas Manuales [8 h]; Operario [8 h]; Peón [8 h]; Acacia Macracantha (Huarango) [8 Unid]; Ingeniero Residente de Obra [8 h]; Ing. SSOMA [8 h]; Ing. Responsable de Calidad [8 h] | 221.5 |
|  | 4 | **Especies Cubresuelos** |  | 2025-09-08 | 2025-09-14 |  |  |  |  |  |
| A1990 |  | Lippia Nodiflora (Bella Alfombra). Incluye Siembra Y Transporte | 7d | 2025-09-08 | 2025-09-14 | A1980 | 0d |  | Ingeniero Residente de Obra [56 h]; Ing. SSOMA [56 h]; Ing. Responsable de Calidad [56 h]; Operario [56 h]; Peón [56 h]; Lippia Nodiflora (Bella Alfombra) [56 m2]; Herramientas Manuales [56 h] | 290.5 |
|  | 5 | **Formación De Senderos Y Plataformas** |  | 2025-09-15 | 2025-10-01 |  |  |  |  |  |
| A2000 |  | Conformación Y Compactación De Base Granular De Espesor E=0.15m (Incluye Material) | 5d | 2025-09-15 | 2025-09-19 | A1990 | 86d | 0d | Ingeniero Residente de Obra [40 h]; Ing. SSOMA [40 h]; Ing. Responsable de Calidad [40 h]; Operario [40 h]; Peón [40 h]; Material Granular [40 m3]; Agua Puesta en Obra [40 m3]; Herramientas Manuales [40 h]; Compactadora Vibratoria Tipo Plancha 7 HP [40 h] | 4,465.1 |
| A2010 |  | Capa Superficial De Arena De Espesor E=0.05m | 5d | 2025-09-20 | 2025-09-24 | A2000 | 86d | 0d | Ingeniero Residente de Obra [40 h]; Ing. SSOMA [40 h]; Ing. Responsable de Calidad [40 h]; Operario [40 h]; Peón [40 h]; Arena [40 m3]; Agua Puesta en Obra [40 m3]; Herramientas Manuales [40 h] | 3,487.5 |
| A2020 |  | Borde De Troncos De Madera De Altura 15 Cm Sobre El Nivel De Piso Y Altura Total 50 Cm Diámetro 4" | 7d | 2025-09-25 | 2025-10-01 | A2010 | 86d | 0d | Ingeniero Residente de Obra [56 h]; Ing. SSOMA [56 h]; Ing. Responsable de Calidad [56 h]; Operario [56 h]; Peón [56 h]; Tronco de Madera [56 Unid]; Herramientas Manuales [56 h] | 738.5 |
|  | 6 | **Elementos Arquitectónicos** |  | 2025-10-02 | 2025-10-06 |  |  |  |  |  |
| A2030 |  | Baranda Rústica De Madera De Huayruro De Altura H=1.00 M En Terreno Natural | 5d | 2025-10-02 | 2025-10-06 | A2020 | 86d | 0d | Ingeniero Residente de Obra [40 h]; Ing. SSOMA [40 h]; Ing. Responsable de Calidad [40 h]; Operario [40 h]; Peón [40 h]; Clavos para Madera con Cabeza de 2 1/2" [40 kg]; Madera Huayruro [40 P2]; Insecticida Antitermitas [40 gal]; Herramientas Manuales [40 h] | 3,827.5 |
|  | 7 | **Mobiliario Urbano** |  | 2025-10-07 | 2025-10-12 |  |  |  |  |  |
| A2040 |  | Banca De Madera Sobre Gavión. Tipo T2 | 3d | 2025-10-07 | 2025-10-09 | A2030 | 86d | 0d | Ingeniero Residente de Obra [24 h]; Ing. SSOMA [24 h]; Ing. Responsable de Calidad [24 h]; Operario [24 h]; Peón [24 h]; Clavos para Madera con Cabeza de 2 1/2" [24 kg]; Plancha de Acero 8mm [24 kg]; Madera Tornillo [24 P2]; Insecticida Antitermitas [24 gal] | 2,572.5 |
| A2050 |  | Papeleras De Reciclaje De Acabado De Madera En Estructura De 4 (75 Litros C/U) | 1d | 2025-10-10 | 2025-10-10 | A2040 | 86d | 0d | Ingeniero Residente de Obra [8 h]; Ing. SSOMA [8 h]; Ing. Responsable de Calidad [8 h]; Operario [8 h]; Peón [8 h]; Herramientas Manuales [8 h]; Papelera de Reciclaje [8 Unid] | 9,641.5 |
| A2060 |  | Piedra Ornamental Para Espacio Público | 2d | 2025-10-11 | 2025-10-12 | A2050 | 86d | 0d | Ingeniero Residente de Obra [16 h]; Ing. SSOMA [16 h]; Ing. Responsable de Calidad [16 h]; Operario [16 h]; Peón [16 h]; Herramientas Manuales [16 h] | 83 |
|  | 8 | **Señalética Informativa** |  | 2025-10-13 | 2025-10-14 |  |  |  |  |  |
| A2070 |  | Panel Informativo H=1.25m. Tipo A | 1d | 2025-10-13 | 2025-10-13 | A2060 | 90d | 0d | Herramientas Manuales [8 h]; Ingeniero Residente de Obra [8 h]; Ing. SSOMA [8 h]; Operario [8 h]; Peón [8 h]; Clavos para Madera con Cabeza de 2 1/2" [8 kg]; Hormigon [8 m3]; Agua Puesta en Obra [8 m3]; Banner Señalitica Digital [8 Unid]; Cemento Porland Tipo I (42.5 kg) [8 bol]; Madera Tornillo [8 P2] | 1,595.9 |
| A2080 |  | Panel Informativo H=2.10m. Tipo B | 1d | 2025-10-14 | 2025-10-14 | A2070 | 90d |  | Ingeniero Residente de Obra [8 h]; Ing. SSOMA [8 h]; Operario [8 h]; Peón [8 h]; Clavos para Madera con Cabeza de 2 1/2" [8 kg]; Hormigon [8 m3]; Agua Puesta en Obra [8 m3]; Banner Señalitica Digital [8 Unid]; Cemento Porland Tipo I (42.5 kg) [8 bol]; Madera Tornillo [8 P2]; Herramientas Manuales [8 h] | 1,595.9 |
|  | 9 | **Obras De Concreto Armado** |  | 2025-10-13 | 2025-10-18 |  |  |  |  |  |
| A2090 |  | Excavación En Material Suelto, Con Equipo | 1d | 2025-10-13 | 2025-10-13 | A2060 | 86d | 0d | Ingeniero Residente de Obra [8 h]; Ing. SSOMA [8 h]; Peón [8 h]; Retroexcavadora Case 590 SK [8 h] | 1,501.28 |
| A2100 |  | Conformación De Dme/Dmo | 1d | 2025-10-14 | 2025-10-14 | A2090 | 86d | 0d | Ingeniero Residente de Obra [8 h]; Ing. SSOMA [8 h]; Ing. Responsable de Calidad [8 h]; Operario [8 h]; Peón [8 h]; Agua Puesta en Obra [8 m3]; Herramientas Manuales [8 h]; Compactadora Vibratoria Tipo Plancha 7 HP [8 h] | 449.02 |
| A2120 |  | Acero En Barras Corrugadas (Fy=420mpa) | 1d | 2025-10-15 | 2025-10-15 | A2130 SS | 89d |  | Ingeniero Residente de Obra [8 h]; Ing. SSOMA [8 h]; Operario [8 h]; Peón [8 h]; Alambre Negro Recocido N° 16 [8 kg]; Acero Corrugado fy= 4200 kg/cm2 Grado 60 [8 kg]; Herramientas Manuales [8 h] | 108.22 |
| A2130 |  | Encofrado Y Desencofrado | 1d | 2025-10-15 | 2025-10-15 | A2100 | 86d | 0d | Herramientas Manuales [8 h]; Ingeniero Residente de Obra [8 h]; Ing. SSOMA [8 h]; Operario [8 h]; Peón [8 h]; Alambre Negro Recocido N° 08 [8 kg]; Clavos para Madera con Cabeza de 2 1/2" [8 kg]; Madera Tornillo [8 P2] | 178.78 |
| A2110 |  | Concreto (F'c = 21 Mpa) En Cimentación | 1d | 2025-10-16 | 2025-10-16 | A2130 | 86d | 0d | Ingeniero Residente de Obra [8 h]; Ing. SSOMA [8 h]; Ing. Responsable de Calidad [8 h]; Operario [8 h]; Peón [8 h]; Piedra Chancada 1/2" [8 m3]; Arena Gruesa [8 m3]; Agua Puesta en Obra [8 m3]; Cemento Porland Tipo I (42.5 kg) [8 bol]; Herramientas Manuales [8 h]; Vibrador de Concreto 4 HP 1.25" [8 h]; Mezcladora de Concreto 11 P3 (23 HP) [8 h] | 1,662.7 |
| A2170 |  | Perno De Anclaje Ø1/4" Expansivo A307 L=114mm | 1d | 2025-10-16 | 2025-10-16 | A2110 SS | 88d |  | Ingeniero Residente de Obra [8 h]; Ing. SSOMA [8 h]; Operario [8 h]; Peón [8 h]; Perno de Anclaje de 1/4" Expansivo A307 L=114 mm [8 Unid]; Herramientas Manuales [8 h] | 141.5 |
| A2140 |  | Acero Estructural A36 | 1d | 2025-10-17 | 2025-10-17 | A2110 | 87d |  | Ingeniero Residente de Obra [8 h]; Ing. SSOMA [8 h]; Operario [8 h]; Peón [8 h]; Acero Estructural A36 [8 kg]; Herramientas Manuales [8 h] | 149.5 |
| A2180 |  | Tubo Astm A500/A500m | 1d | 2025-10-17 | 2025-10-17 | A2110 | 86d | 0d | Ingeniero Residente de Obra [8 h]; Ing. SSOMA [8 h]; Operario [8 h]; Peón [8 h]; Tubo ASTM A500/A500M [8 m]; Herramientas Manuales [8 h] | 157.5 |
| A2150 |  | Tornillo Galvanizado Ø1/4" Pasante A307 (Incluido Con Tuerca Y Arandela Plana) | 1d | 2025-10-18 | 2025-10-18 | A2180 | 86d | 0d | Herramientas Manuales [8 h]; Ingeniero Residente de Obra [8 h]; Ing. SSOMA [8 h]; Operario [8 h]; Peón [8 h]; Tornillo Galvanizado D=1/4" Pasante A307 [8 Unid]; Arandela Plana de 1/4" [8 Unid]; Tuerca 1/4" [8 Unid] | 147.1 |
| A2160 |  | Perno De Anclaje Ø1/4" Expansivo A307 L=57mm | 1d | 2025-10-18 | 2025-10-18 | A2150 SS | 86d |  | Ingeniero Residente de Obra [8 h]; Ing. SSOMA [8 h]; Operario [8 h]; Peón [8 h]; Perno de Anclaje de 1/4" Expansivo A307 L=57 mm [8 Unid]; Herramientas Manuales [8 h] | 101.5 |

| ID | WBS | Activity | Duration | Start | Finish | Predecessors | Total float | Resources | Cost |
| --- | --- | --- | --- | --- | --- | --- | --- | --- | --- |
|  | 10 | **Mantenimiento Post Plantación** |  | 2025-08-10 | 2026-01-12 |  |  |  |  |
| A2230 |  | Limpieza de Mala Hierba y Recalce | 156d | 2025-08-10 | 2026-01-12 | A1750 | 0d | Ingeniero Residente de Obra [1248 h]; Ing. SSOMA [1248 h]; Operario [1248 h]; Peón [1248 h]; Herramientas Manuales [1248 h] | 7,321.08 |
|  | 1 | **Mantenimiento de Vegetación Arborea** |  | 2025-09-15 | 2026-01-12 |  |  |  |  |
| A2730 |  | Deshierve | 120d | 2025-09-15 | 2026-01-12 | A1990 | 0d |  |  |
| A2740 |  | Control de Plagas | 120d | 2025-09-15 | 2026-01-12 | A1990 | 0d |  |  |
| A2750 |  | Poda | 120d | 2025-09-15 | 2026-01-12 | A1990 | 0d |  |  |
| A2760 |  | Recalce | 120d | 2025-09-15 | 2026-01-12 | A1990 | 0d |  |  |
|  | 2 | **Mantenimiento de Vegetación Arbustiva** |  | 2025-09-15 | 2026-01-12 |  |  |  |  |
| A2770 |  | Deshierva | 120d | 2025-09-15 | 2026-01-12 | A1990 | 0d |  |  |
| A2780 |  | Recalce | 120d | 2025-09-15 | 2026-01-12 | A1990 | 0d |  |  |
|  | 3 | **Bioestimulación** |  | 2025-09-15 | 2026-01-12 |  |  |  |  |
| A2790 |  | Aplicación de Enraizante | 120d | 2025-09-15 | 2026-01-12 | A1990 | 0d |  |  |
|  | 4 | **Fertilización Quimica** |  | 2025-09-15 | 2026-01-12 |  |  |  |  |
| A2800 |  | Fertilización de liberación lenta NPK | 120d | 2025-09-15 | 2026-01-12 | A1990 | 0d |  |  |
| A2810 |  | Aplicación Foliar Bioestimulantes | 120d | 2025-09-15 | 2026-01-12 | A1990 | 0d |  |  |
|  | 5 | **Aplicación de Micorrizas** |  | 2025-09-15 | 2026-01-12 |  |  |  |  |
| A2820 |  | Aplicación de Microrrizas | 120d | 2025-09-15 | 2026-01-12 | A1990 | 0d |  |  |
|  | 6 | **Monitoreo de Plantaciones** |  | 2025-09-15 | 2026-01-12 |  |  |  |  |
| A2830 |  | Monitoreo | 120d | 2025-09-15 | 2026-01-12 | A1990 | 0d |  |  |
